# Keller

Schedule from MS Project, 2018-07-02 to 2018-11-01, A marks actual dates.
Bechtle IT-Systemhaus Mannheim

## Calendars

- Standard: Mon-Fri 08:00-12:00, 13:00-17:00; Sat-Sun off. Exceptions (off unless hours are given): 2018-10-03, 2018-11-01.

## Schedule

| ID | WBS | Task | Type | Duration | Start | Finish | Predecessors | Complete | Remaining | Baseline start | Baseline finish | Baseline duration | Total slack |
| --- | --- | --- | --- | --- | --- | --- | --- | --- | --- | --- | --- | --- | --- |
| 1 | 1 | Planfeststellung mit Beteiligten | manual | 1d | 2018-07-03 | 2018-07-03 |  |  |  | 2018-07-03 | 2018-07-03 | 1d |  |
| 2 | 2 | Baustelleneinrichtung |  | 3d | 2018-07-02 A | 2018-07-04 A |  | 100% |  | 2018-07-02 | 2018-07-04 | 3d |  |
| 3 | 3 | **Bodenplatte** |  | 41d | 2018-07-10 A | 2018-09-04 |  | 19% | 33.36d | 2018-07-10 | 2018-08-29 | 37d | 0d |
| 4 | 3.1 | Ausheben |  | 10d | 2018-07-10 A | 2018-07-23 A | 2FS+3d | 100% |  | 2018-07-10 | 2018-07-18 | 7d |  |
| 5 | 3.2 | Schalung |  | 3d | 2018-07-25 A | 2018-07-27 A | 4 | 100% |  | 2018-07-19 | 2018-07-23 | 3d |  |
| 6 | 3.3 | Armierung |  | 5d | 2018-07-30 A | 2018-08-03 A | 5 | 100% |  | 2018-07-24 | 2018-07-30 | 5d |  |
| 7 | 3.4 | Abnahme |  | 1d | 2018-08-06 A | 2018-08-06 A | 6 | 100% |  | 2018-07-31 | 2018-07-31 | 1d |  |
| 8 | 3.5 | Betonieren |  | 1d | 2018-08-07 | 2018-08-07 | 7 |  |  | 2018-08-01 | 2018-08-01 | 1d | 0d |
| 9 | 3.6 | Trocknen |  | 27ed | 2018-08-07 | 2018-09-03 | 8 |  |  | 2018-08-01 | 2018-08-28 | 27ed | 1.88d |
| 10 | 3.7 | Endabnahme |  | 1d | 2018-09-04 | 2018-09-04 | 9 |  |  | 2018-08-29 | 2018-08-29 | 1d | 0d |
| 11 | 4 | **Wände einziehen** |  | 15d | 2018-09-03 | 2018-09-21 |  |  |  | 2018-08-28 | 2018-09-17 | 15d | 0d |
| 12 | 4.1 | Anlieferung Steine |  | 1d | 2018-09-03 | 2018-09-03 | 10FS-2d |  |  | 2018-08-28 | 2018-08-28 | 1d | 2.5d |
| 13 | 4.2 | Aufbau Mörtelsilo |  | 0.5d | 2018-09-05 | 2018-09-05 | 10 |  |  | 2018-08-30 | 2018-08-30 | 0.5d | 0d |
| 14 | 4.3 | Lieferung Mörtel |  | 1d | 2018-09-05 | 2018-09-06 | 13 |  |  | 2018-08-30 | 2018-08-31 | 1d | 0d |
| 15 | 4.4 | Maurerarbeiten |  | 8d | 2018-09-10 | 2018-09-19 | 12FS+1.5d, 14FS+1.5d |  |  | 2018-09-04 | 2018-09-13 | 8d | 0d |
| 16 | 4.5 | Abnahme |  | 1d | 2018-09-21 | 2018-09-21 | 15FS+1d |  |  | 2018-09-17 | 2018-09-17 | 1d | 0d |
| 17 | 5 | **Kellerdecke** |  | 27d | 2018-09-24 | 2018-11-01 |  |  |  | 2018-09-18 | 2018-10-25 | 27d | 0d |
| 18 | 5.1 | Schalung |  | 4d | 2018-09-24 | 2018-09-27 | 16 |  |  | 2018-09-18 | 2018-09-21 | 4d | 0d |
| 19 | 5.2 | Armierung |  | 3d | 2018-09-28 | 2018-10-02 | 18 |  |  | 2018-09-24 | 2018-09-26 | 3d | 0d |
| 20 | 5.3 | Abnahme |  | 1d | 2018-10-04 | 2018-10-04 | 19 |  |  | 2018-09-27 | 2018-09-27 | 1d | 0d |
| 21 | 5.4 | Betonieren |  | 1d | 2018-10-05 | 2018-10-05 | 20 |  |  | 2018-09-28 | 2018-09-28 | 1d | 0d |
| 22 | 5.5 | Trocknen |  | 27ed | 2018-10-05 | 2018-11-01 | 21 |  |  | 2018-09-28 | 2018-10-25 | 27ed | 0d |
